# detail_inception_iteration

Schedule from MS Project, 1999-05-03 to 1999-09-07, costs in $, A marks actual dates.
Rational Software Corporation

## Calendars

- Standard: Mon-Fri 08:00-12:00, 13:00-17:00; Sat-Sun off.

## Resources

| Resource | Rate |
| --- | --- |
| Architect |  |
| Architecture Reviewer | 50 |
| Business-Process Analyst | 55 |
| Business Designer | 50 |
| Business-Model Reviewer | 50 |
| Code Reviewer | 45 |
| Configuration Manager | 70 |
| Course Developer | 40 |
| Database Designer | 75 |
| Deployment Manager | 60 |
| Design Reviewer | 45 |
| Designer | 50 |
| Implementer | 45 |
| Integration Tester | 45 |
| Performance Tester | 60 |
| Process Engineer | 65 |
| Project Manager | 75 |
| Requirements Reviewer | 45 |
| Stakeholder | 75 |
| System Administrator | 40 |
| System Analyst | 55 |
| System Integrator | 45 |
| System Tester | 45 |
| Technical Writer | 35 |
| Test Designer | 40 |
| Tool Smith | 40 |
| Use-Case Specifier | 45 |
| User-Interface Designer | 55 |
| Project Reviewer | 50 |
| Architectsys | 75 |
| Change Control Manager | 70 |
| Any Worker | 25 |
| Software Architect | 65 |
| Tool Specialist | 40 |

## Schedule

| ID | WBS | Task | Type | Duration | Start | Finish | Predecessors | Complete | Remaining | Baseline start | Baseline finish | Baseline duration | Total slack | Constraint | Resources | Work | Actual work | Cost | Baseline cost | Actual cost | Text1 | Text2 | Text4 |
| --- | --- | --- | --- | --- | --- | --- | --- | --- | --- | --- | --- | --- | --- | --- | --- | --- | --- | --- | --- | --- | --- | --- | --- |
| 1 | 1 | **Inception Phase** |  | 92d | 1999-05-03 A | 1999-09-07 |  | 9% | 83.42d | 1999-05-03 | 1999-08-02 | 66d | 0d |  |  | 1985.92h | 165.6h | 113,625.6 | 109,425.6 | 10,512 | Requirements continue to be added during Construction | Move out Implementation Date | Defer all new requirements |
| 2 | 1.1 | **Project Management** |  | 92d | 1999-05-03 A | 1999-09-07 |  | 12% | 80.65d | 1999-05-03 | 1999-08-02 | 66d | 0d |  |  | 588h | 76h | 40,500 | 36,300 | 5,500 | QA Environment needs to be setup | Testing cannot be done until setup | Get QA Environment setup ASAP |
| 3 | 1.1.1 | **Conceive New Project** |  | 3d | 1999-05-03 A | 1999-05-05 A |  | 100% |  | 1999-05-03 | 1999-05-05 | 3d |  |  |  | 40h | 40h | 2,800 | 2,200 | 2,800 | Too many major system changes at one time | Makes QA Test Time Difficult | Minimize system changes until after Imp. |
| 4 | 1.1.1.1 | Identify and Assess Risks | milestone | 2d | 1999-05-03 A | 1999-05-04 A |  | 100% |  | 1999-05-03 | 1999-05-03 | 1d |  |  | Project Manager | 16h | 16h | 1,200 | 600 | 1,200 | Lack of repeatable installation process | Code in various Env. Does not match | Complete Install programs ASAP |
| 5 | 1.1.1.2 | Develop Business Case | milestone | 1d | 1999-05-04 A | 1999-05-04 A | 4 | 100% |  | 1999-05-04 | 1999-05-04 | 1d |  |  | Project Manager | 8h | 8h | 600 | 600 | 600 | Decrease in available resources for QA | Timelines will continue to stretch | Hire needed resources ASAP |
| 6 | 1.1.1.3 | Initiate Project | milestone | 1d | 1999-05-05 A | 1999-05-05 A | 5 | 100% |  | 1999-05-05 | 1999-05-05 | 1d |  |  | Project Manager | 8h | 8h | 600 | 600 | 600 | Lack of repeatable unit testing process | Increased test phase due to poor code quality | Hold Developers Accountable for Unit testing |
| 7 | 1.1.1.4 | Project Approval Review | milestone | 1d | 1999-05-05 A | 1999-05-05 A | 6FF | 100% |  | 1999-05-05 | 1999-05-05 | 1d |  |  | Project Reviewer | 8h | 8h | 400 | 400 | 400 |  |  |  |
| 8 | 1.1.2 | **Evaluate Project Scope and Risk** |  | 3d | 1999-05-06 A | 1999-05-10 A | 4, 3 | 100% |  | 1999-05-06 | 1999-05-07 | 2d |  |  |  | 32h | 32h | 2,400 | 1,200 | 2,400 |  |  |  |
| 9 | 1.1.2.1 | Identify and Assess Risks |  | 3d | 1999-05-06 A | 1999-05-10 A |  | 100% |  | 1999-05-06 | 1999-05-06 | 1d |  |  | Project Manager | 24h | 24h | 1,800 | 600 | 1,800 |  |  |  |
| 10 | 1.1.2.2 | Develop Business Case |  | 1d | 1999-05-07 A | 1999-05-07 A | 9 | 100% |  | 1999-05-07 | 1999-05-07 | 1d |  |  | Project Manager | 8h | 8h | 600 | 600 | 600 |  |  |  |
| 11 | 1.1.3 | **Develop Software Development Plan** |  | 33d | 1999-06-01 | 1999-07-15 | 52SS, 8 |  |  | 1999-05-31 | 1999-06-09 | 8d | 0d |  |  | 104h |  | 7,600 | 5,200 |  |  |  |  |
| 12 | 1.1.3.1 | Develop Measurement Plan |  | 5d | 1999-06-01 | 1999-06-08 |  |  |  | 1999-05-31 | 1999-05-31 | 1d | 0d | finish no earlier than 1999-06-04 | Project Manager | 40h |  | 3,000 | 600 |  |  |  |  |
| 13 | 1.1.3.2 | Develop Risk Management Plan |  | 1d | 1999-06-08 | 1999-06-15 | 12 |  |  | 1999-06-01 | 1999-06-01 | 1d | 0d |  | Project Manager | 8h |  | 600 | 600 |  |  |  |  |
| 14 | 1.1.3.3 | Develop Product Acceptance Plan |  | 1d | 1999-06-15 | 1999-06-21 | 13 |  |  | 1999-06-02 | 1999-06-02 | 1d | 0d |  | Project Manager | 8h |  | 600 | 600 |  |  |  |  |
| 15 | 1.1.3.4 | Develop Problem Resolution Plan |  | 1d | 1999-06-22 | 1999-06-28 | 14 |  |  | 1999-06-03 | 1999-06-03 | 1d | 0d |  | Project Manager | 8h |  | 600 | 600 |  |  |  |  |
| 16 | 1.1.3.5 | Define Project Organization and Staffing |  | 1d | 1999-06-28 | 1999-07-01 | 15 |  |  | 1999-06-04 | 1999-06-04 | 1d | 0d |  | Project Manager | 8h |  | 600 | 600 |  |  |  |  |
| 17 | 1.1.3.6 | Define Monitoring & Control Processes |  | 1d | 1999-07-01 | 1999-07-07 | 16 |  |  | 1999-06-07 | 1999-06-07 | 1d | 0d |  | Project Manager | 8h |  | 600 | 600 |  |  |  |  |
| 18 | 1.1.3.7 | Plan Phases and Iterations |  | 1d | 1999-07-07 | 1999-07-12 | 17 |  |  | 1999-06-08 | 1999-06-08 | 1d | 0d |  | Project Manager | 8h |  | 600 | 600 |  |  |  |  |
| 19 | 1.1.3.8 | Compile Software Development Plan |  | 1d | 1999-07-12 | 1999-07-15 | 18 |  |  | 1999-06-09 | 1999-06-09 | 1d | 0d |  | Project Manager | 8h |  | 600 | 600 |  |  |  |  |
| 20 | 1.1.3.9 | Project Planning Review |  | 1d | 1999-07-12 | 1999-07-15 | 19FF |  |  | 1999-06-09 | 1999-06-09 | 1d | 0d |  | Project Reviewer | 8h |  | 400 | 400 |  |  |  |  |
| 21 | 1.1.4 | **Plan for Next Iteration** |  | 3d | 1999-07-16 | 1999-07-20 | 11 |  |  | 1999-06-10 | 1999-06-14 | 3d | 0d |  |  | 24h |  | 1,600 | 1,600 |  |  |  |  |
| 22 | 1.1.4.1 | Develop Iteration Plan |  | 1d | 1999-07-16 | 1999-07-16 |  |  |  | 1999-06-10 | 1999-06-10 | 1d | 0d |  | Project Manager | 8h |  | 600 | 600 |  |  |  |  |
| 23 | 1.1.4.2 | Develop Business Case |  | 1d | 1999-07-19 | 1999-07-19 | 22 |  |  | 1999-06-11 | 1999-06-11 | 1d | 0d |  | Project Manager | 8h |  | 600 | 600 |  |  |  |  |
| 24 | 1.1.4.3 | Iteration Plan Review |  | 1d | 1999-07-20 | 1999-07-20 | 23 |  |  | 1999-06-14 | 1999-06-14 | 1d | 0d |  | Project Reviewer | 8h |  | 400 | 400 |  |  |  |  |

| ID | WBS | Task | Duration | Start | Finish | Predecessors | Complete | Remaining | Baseline start | Baseline finish | Baseline duration | Total slack | Free slack | Constraint | Resources | Work | Actual work | Cost | Baseline cost | Actual cost |
| --- | --- | --- | --- | --- | --- | --- | --- | --- | --- | --- | --- | --- | --- | --- | --- | --- | --- | --- | --- | --- |
| 25 | 1.1.5 | **Manage Iteration** | 43.8d | 1999-06-17 A | 1999-08-17 | 21 | 2% | 42.92d | 1999-06-15 | 1999-07-12 | 20d | 13d | 0d |  |  | 200h | 4h | 13,000 | 13,000 | 300 |
| 26 | 1.1.5.1 | Acquire Staff | 5d | 1999-06-17 A | 1999-07-27 |  | 10% | 4.5d | 1999-06-15 | 1999-06-21 | 5d | 0.5d | 0d |  | Project Manager | 40h | 4h | 3,000 | 3,000 | 300 |
| 27 | 1.1.5.2 | Initiate Iteration | 5d | 1999-07-27 | 1999-08-03 | 26 |  |  | 1999-06-22 | 1999-06-28 | 5d | 0.5d |  |  | Project Manager | 40h |  | 3,000 | 3,000 |  |
| 28 | 1.1.5.3 | Assess Iteration | 5d | 1999-08-04 | 1999-08-10 | 73FF, 27 |  |  | 1999-06-29 | 1999-07-05 | 5d | 0d |  |  | Project Manager | 40h |  | 3,000 | 3,000 |  |
| 29 | 1.1.5.4 | Iteration Evaluation Criteria Review | 5d | 1999-08-04 | 1999-08-10 | 28FF |  |  | 1999-06-29 | 1999-07-05 | 5d | 13d | 0d |  | Project Reviewer | 40h |  | 2,000 | 2,000 |  |
| 30 | 1.1.5.5 | Iteration Acceptance Review | 5d | 1999-08-11 | 1999-08-17 | 29 |  |  | 1999-07-06 | 1999-07-12 | 5d | 13d |  |  | Project Reviewer | 40h |  | 2,000 | 2,000 |  |
| 31 | 1.1.6 | **Monitor and Control Project** | 20d | 1999-08-11 | 1999-09-07 | 11, 25SS |  |  | 1999-07-06 | 1999-08-02 | 20d | 0d |  |  |  | 180h |  | 12,500 | 12,500 |  |
| 32 | 1.1.6.1 | Schedule and Assign Work | 5d | 1999-08-11 | 1999-08-17 | 26, 27, 28 |  |  | 1999-07-06 | 1999-07-12 | 5d | 0d |  |  | Project Manager | 40h |  | 3,000 | 3,000 |  |
| 33 | 1.1.6.2 | Monitor Project Status | 5d | 1999-08-18 | 1999-08-24 | 32 |  |  | 1999-07-13 | 1999-07-19 | 5d | 0d |  |  | Project Manager [50%] | 20h |  | 1,500 | 1,500 |  |
| 34 | 1.1.6.3 | Report Status | 5d | 1999-08-25 | 1999-08-31 | 33 |  |  | 1999-07-20 | 1999-07-26 | 5d | 0d |  |  | Project Manager | 40h |  | 3,000 | 3,000 |  |
| 35 | 1.1.6.4 | Handle Exceptions and Problems | 5d | 1999-09-01 | 1999-09-07 | 34 |  |  | 1999-07-27 | 1999-08-02 | 5d | 0d |  |  | Project Manager | 40h |  | 3,000 | 3,000 |  |
| 36 | 1.1.6.5 | Project Review Authority (PRA) Project Review | 5d | 1999-09-01 | 1999-09-07 | 35FF |  |  | 1999-07-27 | 1999-08-02 | 5d | 0d |  |  | Project Reviewer | 40h |  | 2,000 | 2,000 |  |
| 37 | 1.1.7 | **Reevaluate Project Scope and Risk** | 2d | 1999-08-18 | 1999-08-19 | 25, 65SS |  |  | 1999-07-13 | 1999-07-14 | 2d | 13d |  |  |  | 8h |  | 600 | 600 |  |
| 38 | 1.1.7.1 | Identify and Assess Risks | 1d | 1999-08-18 | 1999-08-18 |  |  |  | 1999-07-13 | 1999-07-13 | 1d | 13d | 0d |  | Project Manager [50%] | 4h |  | 300 | 300 |  |
| 39 | 1.1.7.2 | Develop Business Case | 1d | 1999-08-19 | 1999-08-19 | 38 |  |  | 1999-07-14 | 1999-07-14 | 1d | 13d |  |  | Project Manager [50%] | 4h |  | 300 | 300 |  |
| 40 | 1.2 | **Requirements** | 68.2d | 1999-05-03 A | 1999-08-05 |  | 18% | 56.16d | 1999-05-03 | 1999-06-24 | 39d | 23.8d |  |  |  | 445.92h | 66.4h | 23,485.6 | 23,485.6 | 3,652 |
| 41 | 1.2.1 | **Analyze the Problem** | 16d | 1999-05-03 A | 1999-05-24 | 3SS, 46SS | 53% | 7.6d | 1999-05-03 | 1999-05-24 | 16d | 55.8d | 5d |  |  | 64h | 33.6h | 3,520 | 3,520 | 1,848 |
| 42 | 1.2.1.1 | Capture a Common Vocabulary | 4d | 1999-05-03 A | 1999-05-07 |  | 90% | 0.4d | 1999-05-03 | 1999-05-06 | 4d | 67.6d |  |  | System Analyst [50%] | 16h | 14.4h | 880 | 880 | 792 |
| 43 | 1.2.1.2 | Find Actors and Use Cases | 4d | 1999-05-07 A | 1999-05-12 A | 42 | 100% |  | 1999-05-07 | 1999-05-12 | 4d |  |  |  | System Analyst [50%] | 16h | 16h | 880 | 880 | 880 |
| 44 | 1.2.1.3 | Develop Vision | 4d | 1999-05-13 A | 1999-05-18 | 43 | 20% | 3.2d | 1999-05-13 | 1999-05-18 | 4d | 55.8d | 0d |  | System Analyst [50%] | 16h | 3.2h | 880 | 880 | 176 |
| 45 | 1.2.1.4 | Develop Requirements Management Plan | 4d | 1999-05-19 | 1999-05-24 | 44 |  |  | 1999-05-19 | 1999-05-24 | 4d | 55.8d |  |  | System Analyst [50%] | 16h |  | 880 | 880 |  |
| 46 | 1.2.2 | **Understand Stakeholder Needs** | 20d | 1999-05-04 A | 1999-05-31 | 3SS | 41% | 11.8d | 1999-05-03 | 1999-05-28 | 20d | 50.8d | 0d |  |  | 80h | 32.8h | 4,400 | 4,400 | 1,804 |
| 47 | 1.2.2.1 | Capture a Common Vocabulary | 4d | 1999-05-04 A | 1999-05-07 A |  | 100% |  | 1999-05-03 | 1999-05-06 | 4d |  |  | finish no earlier than 1999-05-07 | System Analyst [50%] | 16h | 16h | 880 | 880 | 880 |
| 48 | 1.2.2.2 | Elicit Stakeholder Requests | 4d | 1999-05-10 A | 1999-05-13 | 47 | 90% | 0.4d | 1999-05-07 | 1999-05-12 | 4d | 51.4d | 0d |  | System Analyst [50%] | 16h | 14.4h | 880 | 880 | 792 |
| 49 | 1.2.2.3 | Develop Vision | 4d | 1999-05-14 A | 1999-05-19 | 48 | 15% | 3.4d | 1999-05-13 | 1999-05-18 | 4d | 50.8d | 0d |  | System Analyst [50%] | 16h | 2.4h | 880 | 880 | 132 |
| 50 | 1.2.2.4 | Find Actors and Use Cases | 4d | 1999-05-20 | 1999-05-25 | 49 |  |  | 1999-05-19 | 1999-05-24 | 4d | 50.8d | 0d |  | System Analyst [50%] | 16h |  | 880 | 880 |  |
| 51 | 1.2.2.5 | Manage Dependencies | 4d | 1999-05-26 | 1999-05-31 | 50 |  |  | 1999-05-25 | 1999-05-28 | 4d | 50.8d |  |  | System Analyst [50%] | 16h |  | 880 | 880 |  |

| ID | WBS | Task | Duration | Start | Finish | Predecessors | Baseline start | Baseline finish | Baseline duration | Total slack | Free slack | Resources | Work | Cost | Baseline cost |
| --- | --- | --- | --- | --- | --- | --- | --- | --- | --- | --- | --- | --- | --- | --- | --- |
| 52 | 1.2.3 | **Define the System** | 9d | 1999-06-01 | 1999-06-11 | 41, 46 | 1999-05-31 | 1999-06-10 | 9d | 50.8d | 0d |  | 27.84h | 1,531.2 | 1,531.2 |
| 53 | 1.2.3.1 | Capture a Common Vocabulary | 3d | 1999-06-01 | 1999-06-03 |  | 1999-05-31 | 1999-06-02 | 3d | 50.8d | 0d | System Analyst [50%] | 12h | 660 | 660 |
| 54 | 1.2.3.2 | Find Actors and Use Cases | 3d | 1999-06-04 | 1999-06-08 | 53 | 1999-06-03 | 1999-06-07 | 3d | 50.8d | 0d | System Analyst [33%] | 7.92h | 435.6 | 435.6 |
| 55 | 1.2.3.3 | Manage Dependencies | 3d | 1999-06-09 | 1999-06-11 | 54 | 1999-06-08 | 1999-06-10 | 3d | 50.8d |  | System Analyst [33%] | 7.92h | 435.6 | 435.6 |
| 56 | 1.2.4 | **Manage the Scope of the System** | 8d | 1999-06-02 | 1999-06-11 | 52SS+1d | 1999-06-01 | 1999-06-10 | 8d | 55.8d |  |  | 39.84h | 2,431.2 | 2,431.2 |
| 57 | 1.2.4.1 | Develop Vision | 3d | 1999-06-04 | 1999-06-08 | 53 | 1999-06-03 | 1999-06-07 | 3d | 65d |  | System Analyst [33%] | 7.92h | 435.6 | 435.6 |
| 58 | 1.2.4.2 | Manage Dependencies | 3d | 1999-06-09 | 1999-06-11 | 54 | 1999-06-08 | 1999-06-10 | 3d | 62d |  | System Analyst [33%] | 7.92h | 435.6 | 435.6 |
| 59 | 1.2.4.3 | Prioritize Use Cases | 3d | 1999-06-02 | 1999-06-04 |  | 1999-06-01 | 1999-06-03 | 3d | 55.8d | 32d | Software Architect | 24h | 1,560 | 1,560 |
| 60 | 1.2.5 | **Refine the System Definition** | 11.2d | 1999-07-21 | 1999-08-05 | 21, 52, 59 | 1999-06-15 | 1999-06-24 | 8d | 23.8d |  |  | 128h | 6,400 | 6,400 |
| 61 | 1.2.5.1 | Detail a Use Case | 4d | 1999-07-21 | 1999-07-28 |  | 1999-06-15 | 1999-06-18 | 4d | 23.8d | 0d | Use-Case Specifier | 32h | 1,440 | 1,440 |
| 62 | 1.2.5.2 | Detail the Software Requirements | 4d | 1999-07-28 | 1999-08-05 | 61 | 1999-06-21 | 1999-06-24 | 4d | 23.8d |  | Use-Case Specifier | 32h | 1,440 | 1,440 |
| 63 | 1.2.5.3 | Model the User Interface | 4d | 1999-07-21 | 1999-07-28 |  | 1999-06-15 | 1999-06-18 | 4d | 23.8d | 0d | User-Interface Designer | 32h | 1,760 | 1,760 |
| 64 | 1.2.5.4 | Prototype the User Interface | 4d | 1999-07-28 | 1999-08-05 | 63 | 1999-06-21 | 1999-06-24 | 4d | 23.8d |  | User-Interface Designer | 32h | 1,760 | 1,760 |
| 65 | 1.2.6 | **Manage Changing Requirements** | 16d | 1999-05-26 | 1999-06-16 | 41SS+2d | 1999-05-25 | 1999-06-15 | 16d | 57.1d |  |  | 106.24h | 5,203.2 | 5,203.2 |
| 66 | 1.2.6.1 | Structure the Use-Case Model | 8d | 1999-05-26 | 1999-06-04 | 49, 50 | 1999-05-25 | 1999-06-03 | 8d | 57.1d | 0d | System Analyst [33%] | 21.12h | 1,161.6 | 1,161.6 |
| 67 | 1.2.6.2 | Manage Dependencies | 8d | 1999-06-07 | 1999-06-16 | 66 | 1999-06-04 | 1999-06-15 | 8d | 57.1d | 0d | System Analyst [33%] | 21.12h | 1,161.6 | 1,161.6 |
| 68 | 1.2.6.3 | Review Requirements | 8d | 1999-06-04 | 1999-06-16 | 67FF | 1999-06-04 | 1999-06-15 | 8d | 59d |  | Requirements Reviewer | 64h | 2,880 | 2,880 |
| 69 | 1.3 | **Analysis and Design** | 15d | 1999-07-21 | 1999-08-10 |  | 1999-06-15 | 1999-07-05 | 15d | 0d |  |  | 120h | 7,800 | 7,800 |
| 70 | 1.3.1 | **Perform Architectural Synthesis** | 15d | 1999-07-21 | 1999-08-10 | 21 | 1999-06-15 | 1999-07-05 | 15d | 0d |  |  | 120h | 7,800 | 7,800 |
| 71 | 1.3.1.1 | Architectural Analysis | 5d | 1999-07-21 | 1999-07-27 |  | 1999-06-15 | 1999-06-21 | 5d | 0d |  | Software Architect | 40h | 2,600 | 2,600 |
| 72 | 1.3.1.2 | Construct Architectural Proof-of-Concept | 5d | 1999-07-28 | 1999-08-03 | 71 | 1999-06-22 | 1999-06-28 | 5d | 0d |  | Software Architect | 40h | 2,600 | 2,600 |
| 73 | 1.3.1.3 | Assess Viability of Architectural Proof-of-Concept | 5d | 1999-08-04 | 1999-08-10 | 72 | 1999-06-29 | 1999-07-05 | 5d | 0d |  | Software Architect | 40h | 2,600 | 2,600 |
| 74 | 1.4 | **Test** | 1d | 1999-06-01 | 1999-06-01 |  | 1999-05-31 | 1999-05-31 | 1d | 70d |  |  | 8h | 320 | 320 |
| 75 | 1.4.1 | **Plan Test** | 1d | 1999-06-01 | 1999-06-01 | 11SS | 1999-05-31 | 1999-05-31 | 1d | 70d |  |  | 8h | 320 | 320 |
| 76 | 1.4.1.1 | Plan Test | 1d | 1999-06-01 | 1999-06-01 |  | 1999-05-31 | 1999-05-31 | 1d | 70d |  | Test Designer | 8h | 320 | 320 |

| ID | WBS | Task | Duration | Start | Finish | Predecessors | Complete | Remaining | Baseline start | Baseline finish | Baseline duration | Total slack | Free slack | Resources | Work | Actual work | Cost | Baseline cost | Actual cost |
| --- | --- | --- | --- | --- | --- | --- | --- | --- | --- | --- | --- | --- | --- | --- | --- | --- | --- | --- | --- |
| 77 | 1.5 | **Environment** | 61.6d | 1999-05-06 A | 1999-07-30 |  | 11% | 54.64d | 1999-05-06 | 1999-06-22 | 34d | 27.4d |  |  | 184h | 20.8h | 9,280 | 9,280 | 1,192 |
| 78 | 1.5.1 | **Prepare Environment for Project** | 3d | 1999-05-06 A | 1999-05-10 | 3 | 65% | 1.05d | 1999-05-06 | 1999-05-10 | 3d | 75.4d | 48d |  | 32h | 20.8h | 1,880 | 1,880 | 1,192 |
| 79 | 1.5.1.1 | Assess Current Organization | 1d | 1999-05-06 A | 1999-05-06 A |  | 100% |  | 1999-05-06 | 1999-05-06 | 1d |  |  | Process Engineer | 8h | 8h | 520 | 520 | 520 |
| 80 | 1.5.1.2 | Develop Development Case | 1d | 1999-05-07 A | 1999-05-07 | 79 | 80% | 0.2d | 1999-05-07 | 1999-05-07 | 1d | 75.4d | 0d | Process Engineer | 8h | 6.4h | 520 | 520 | 416 |
| 81 | 1.5.1.3 | Develop Project-Specific Templates | 1d | 1999-05-10 | 1999-05-10 | 80 |  |  | 1999-05-10 | 1999-05-10 | 1d | 75.4d |  | Process Engineer | 8h |  | 520 | 520 |  |
| 82 | 1.5.1.4 | Select & Acquire Tools | 1d | 1999-05-06 A | 1999-05-06 |  | 80% | 0.2d | 1999-05-06 | 1999-05-06 | 1d | 77.4d | 50d | Tool Specialist | 8h | 6.4h | 320 | 320 | 256 |
| 83 | 1.5.2 | **Prepare Environment for an Iteration** | 3d | 1999-07-16 | 1999-07-20 | 21SS, 78 |  |  | 1999-06-10 | 1999-06-14 | 3d | 27.4d | 0d |  | 40h |  | 2,200 | 2,200 |  |
| 84 | 1.5.2.1 | Develop Development Case | 1d | 1999-07-16 | 1999-07-16 |  |  |  | 1999-06-10 | 1999-06-10 | 1d | 27.4d | 0d | Process Engineer | 8h |  | 520 | 520 |  |
| 85 | 1.5.2.2 | Develop Project-Specific Templates | 1d | 1999-07-19 | 1999-07-19 | 84 |  |  | 1999-06-11 | 1999-06-11 | 1d | 27.4d | 0d | Process Engineer | 8h |  | 520 | 520 |  |
| 86 | 1.5.2.3 | Launch Development Case | 1d | 1999-07-20 | 1999-07-20 | 85 |  |  | 1999-06-14 | 1999-06-14 | 1d | 27.4d |  | Process Engineer | 8h |  | 520 | 520 |  |
| 87 | 1.5.2.4 | Set Up Tools | 1d | 1999-07-16 | 1999-07-16 | 82 |  |  | 1999-06-10 | 1999-06-10 | 1d | 28.4d | 0d | Tool Specialist | 8h |  | 320 | 320 |  |
| 88 | 1.5.2.5 | Verify Tool Configuration & Installation | 1d | 1999-07-19 | 1999-07-19 | 87 |  |  | 1999-06-11 | 1999-06-11 | 1d | 28.4d |  | Tool Specialist | 8h |  | 320 | 320 |  |
| 89 | 1.5.3 | **Prepare Guidelines for an Iteration** | 6.1d | 1999-07-16 | 1999-07-26 | 78, 21SS |  |  | 1999-06-10 | 1999-06-16 | 5d | 31.9d |  |  | 64h |  | 3,280 | 3,280 |  |
| 90 | 1.5.3.1 | Develop Business-Modeling Guidelines | 1d | 1999-07-16 | 1999-07-21 |  |  |  | 1999-06-10 | 1999-06-10 | 1d | 34.9d |  | Business-Process Analyst | 8h |  | 440 | 440 |  |
| 91 | 1.5.3.2 | Develop Use-Case Modeling Guidelines | 1d | 1999-07-16 | 1999-07-19 | 67 |  |  | 1999-06-16 | 1999-06-16 | 1d | 36.1d |  | System Analyst | 8h |  | 440 | 440 |  |
| 92 | 1.5.3.3 | Develop User-Interface Guidelines | 1d | 1999-07-16 | 1999-07-21 |  |  |  | 1999-06-10 | 1999-06-10 | 1d | 34.9d |  | User-Interface Designer | 8h |  | 440 | 440 |  |
| 93 | 1.5.3.4 | Develop Design Guidelines | 1d | 1999-07-16 | 1999-07-21 |  |  |  | 1999-06-10 | 1999-06-10 | 1d | 33.9d | 0d | Software Architect | 8h |  | 520 | 520 |  |
| 94 | 1.5.3.5 | Develop Programming Guidelines | 1d | 1999-07-21 | 1999-07-22 | 93 |  |  | 1999-06-11 | 1999-06-11 | 1d | 33.9d |  | Software Architect | 8h |  | 520 | 520 |  |
| 95 | 1.5.3.6 | Develop Manual Styleguide | 1d | 1999-07-16 | 1999-07-21 |  |  |  | 1999-06-10 | 1999-06-10 | 1d | 34.9d |  | Technical Writer | 8h |  | 280 | 280 |  |
| 96 | 1.5.3.7 | Develop Test Guidelines | 1d | 1999-07-16 | 1999-07-21 |  |  |  | 1999-06-10 | 1999-06-10 | 1d | 34.9d |  | Test Designer | 8h |  | 320 | 320 |  |
| 97 | 1.5.3.8 | Develop Tool Guidelines | 1d | 1999-07-21 | 1999-07-26 | 83 |  |  | 1999-06-15 | 1999-06-15 | 1d | 31.9d |  | Tool Specialist | 8h |  | 320 | 320 |  |
| 98 | 1.5.4 | **Support Environment During an Iteration** | 7.6d | 1999-07-21 | 1999-07-30 | 83 |  |  | 1999-06-15 | 1999-06-22 | 6d | 27.4d |  |  | 48h |  | 1,920 | 1,920 |  |
| 99 | 1.5.4.1 | Support Development | 6d | 1999-07-21 | 1999-07-30 |  |  |  | 1999-06-15 | 1999-06-22 | 6d | 27.4d |  | System Administrator | 48h |  | 1,920 | 1,920 |  |
| 100 | 1.6 | **Configuration & Change Management** | 79.7d | 1999-05-06 A | 1999-08-25 |  |  | 79.46d | 1999-05-06 | 1999-07-14 | 50d | 9.3d |  |  | 640h | 2.4h | 32,240 | 32,240 | 168 |
| 101 | 1.6.1 | **Plan Project Configuration and Change Control** | 3d | 1999-05-06 A | 1999-05-10 | 3 | 10% | 2.7d | 1999-05-06 | 1999-05-10 | 3d | 57.3d | 48d |  | 24h | 2.4h | 1,680 | 1,680 | 168 |
| 102 | 1.6.1.1 | Establish CM Policies | 1d | 1999-05-06 A | 1999-05-06 |  | 20% | 0.8d | 1999-05-06 | 1999-05-06 | 1d | 57.4d | 0d | Configuration Manager | 8h | 1.6h | 560 | 560 | 112 |
| 103 | 1.6.1.2 | Write CM Plan | 1d | 1999-05-07 A | 1999-05-07 | 102 | 5% | 0.95d | 1999-05-07 | 1999-05-07 | 1d | 57.35d | 0d | Configuration Manager | 8h | 0.4h | 560 | 560 | 28 |
| 104 | 1.6.1.3 | Establish Change Control Process | 1d | 1999-05-10 A | 1999-05-10 | 103 | 5% | 0.95d | 1999-05-10 | 1999-05-10 | 1d | 57.3d |  | Change Control Manager | 8h | 0.4h | 560 | 560 | 28 |

| ID | WBS | Task | Duration | Start | Finish | Predecessors | Baseline start | Baseline finish | Baseline duration | Total slack | Free slack | Resources | Work | Cost | Baseline cost |
| --- | --- | --- | --- | --- | --- | --- | --- | --- | --- | --- | --- | --- | --- | --- | --- |
| 105 | 1.6.2 | **Create Project CM Environments** | 3.1d | 1999-07-16 | 1999-07-21 | 21SS, 101 | 1999-06-10 | 1999-06-10 | 1d | 9.3d | 0d |  | 16h | 920 | 920 |
| 106 | 1.6.2.1 | Setup CM Environment | 1d | 1999-07-16 | 1999-07-16 |  | 1999-06-10 | 1999-06-10 | 1d | 11.4d |  | Configuration Manager | 8h | 560 | 560 |
| 107 | 1.6.2.2 | Create Integration Workspaces | 1d | 1999-07-16 | 1999-07-21 |  | 1999-06-10 | 1999-06-10 | 1d | 9.3d |  | System Integrator | 8h | 360 | 360 |
| 108 | 1.6.3 | **Change and Deliver Configuration Items** | 25.6d | 1999-07-21 | 1999-08-25 | 105 | 1999-06-11 | 1999-07-14 | 24d | 9.3d |  |  | 216h | 7,320 | 7,320 |
| 109 | 1.6.3.1 | Create Development Workspace | 6d | 1999-07-21 | 1999-07-30 |  | 1999-06-11 | 1999-06-18 | 6d | 9.3d | 0d | Any Worker [50%] | 24h | 600 | 600 |
| 110 | 1.6.3.2 | Make Changes | 6d | 1999-07-30 | 1999-08-09 | 109 | 1999-06-21 | 1999-06-28 | 6d | 9.3d | 0d | Any Worker [50%] | 24h | 600 | 600 |
| 111 | 1.6.3.3 | Deliver Changes | 6d | 1999-08-09 | 1999-08-17 | 110 | 1999-06-29 | 1999-07-06 | 6d | 9.3d | 0d | Any Worker [50%] | 24h | 600 | 600 |
| 112 | 1.6.3.4 | Update Workspace | 6d | 1999-08-17 | 1999-08-25 | 111 | 1999-07-07 | 1999-07-14 | 6d | 9.3d |  | Any Worker | 48h | 1,200 | 1,200 |
| 113 | 1.6.3.5 | Create Baselines | 6d | 1999-07-21 | 1999-07-29 |  | 1999-06-11 | 1999-06-18 | 6d | 10.9d | 0d | System Integrator | 48h | 2,160 | 2,160 |
| 114 | 1.6.3.6 | Promote Baselines | 6d | 1999-07-29 | 1999-08-06 | 113 | 1999-06-21 | 1999-06-28 | 6d | 10.9d | 0d | System Integrator | 48h | 2,160 | 2,160 |
| 115 | 1.6.4 | **Manage Baselines and Releases** | 24d | 1999-07-21 | 1999-08-24 | 105, 25SS | 1999-06-15 | 1999-07-14 | 22d | 10.9d |  |  | 120h | 6,600 | 6,600 |
| 116 | 1.6.4.1 | Create Deployment Unit | 6d | 1999-07-21 | 1999-07-29 |  | 1999-06-15 | 1999-06-22 | 6d | 16.9d | 0d | Configuration Manager | 48h | 3,360 | 3,360 |
| 117 | 1.6.4.2 | Create Baselines | 6d | 1999-08-06 | 1999-08-16 | 114 | 1999-06-29 | 1999-07-06 | 6d | 10.9d | 0d | System Integrator | 48h | 2,160 | 2,160 |
| 118 | 1.6.4.3 | Promote Baselines | 6d | 1999-08-16 | 1999-08-24 | 117 | 1999-07-07 | 1999-07-14 | 6d | 10.9d | 0d | System Integrator [50%] | 24h | 1,080 | 1,080 |
| 119 | 1.6.5 | **Manage Change Requests** | 24d | 1999-07-21 | 1999-08-24 | 105, 25SS | 1999-06-15 | 1999-07-14 | 22d | 10.9d |  |  | 168h | 9,000 | 9,000 |
| 120 | 1.6.5.1 | Submit Change Request | 6d | 1999-07-21 | 1999-07-29 |  | 1999-06-15 | 1999-06-22 | 6d | 22.9d | 0d | Any Worker [50%] | 24h | 600 | 600 |
| 121 | 1.6.5.2 | Update Change Request | 6d | 1999-07-29 | 1999-08-06 | 120 | 1999-06-23 | 1999-06-30 | 6d | 22.9d |  | Any Worker [50%] | 24h | 600 | 600 |
| 122 | 1.6.5.3 | Review Change Request | 6d | 1999-07-21 | 1999-07-29 |  | 1999-06-15 | 1999-06-22 | 6d | 22.9d | 0d | Change Control Manager | 48h | 3,360 | 3,360 |
| 123 | 1.6.5.4 | Confirm Duplicate or Rejected Change Request | 6d | 1999-07-29 | 1999-08-06 | 122 | 1999-06-23 | 1999-06-30 | 6d | 22.9d |  | Change Control Manager | 48h | 3,360 | 3,360 |
| 124 | 1.6.5.5 | Verify Changes in Build | 6d | 1999-08-16 | 1999-08-24 | 118FF | 1999-07-07 | 1999-07-14 | 6d | 10.9d |  | System Integrator [50%] | 24h | 1,080 | 1,080 |
| 125 | 1.6.6 | **Monitor and Report Configuration Status** | 12d | 1999-07-29 | 1999-08-16 | 105, 25SS | 1999-06-23 | 1999-07-08 | 12d | 16.9d |  |  | 96h | 6,720 | 6,720 |
| 126 | 1.6.6.1 | Report on Configuration Status | 6d | 1999-07-29 | 1999-08-06 | 116 | 1999-06-23 | 1999-06-30 | 6d | 16.9d | 0d | Configuration Manager | 48h | 3,360 | 3,360 |
| 127 | 1.6.6.2 | Perform Configuration Audits | 6d | 1999-08-06 | 1999-08-16 | 126 | 1999-07-01 | 1999-07-08 | 6d | 16.9d |  | Configuration Manager | 48h | 3,360 | 3,360 |
