# detail_inception_iteration

Schedule from MS Project, 1999-05-03 to 1999-05-14.
Rational Software Corporation

## Calendars

- Standard: Mon-Sun 08:00-12:00, 13:00-17:00.

## Resources

| Resource |
| --- |
| Architect |
| Architecture Reviewer |
| Business-Process Analyst |
| Business Designer |
| Business-Model Reviewer |
| Code Reviewer |
| Configuration Manager |
| Course Developer |
| Database Designer |
| Deployment Manager |
| Design Reviewer |
| Designer |
| Implementer |
| Integration Tester |
| Performance Tester |
| Process Engineer |
| Project Manager |
| Requirements Reviewer |
| Stakeholder |
| System Administrator |
| System Analyst |
| System Integrator |
| System Tester |
| Technical Writer |
| Test Designer |
| Tool Smith |
| Use-Case Specifier |
| User-Interface Designer |
| Project Reviewer |
| Architectsys |
| Change Control Manager |
| Any Worker |
| Software Architect |
| Tool Specialist |
| Integrator |

## Schedule

| ID | WBS | Task | Duration | Start | Finish | Predecessors | Total slack | Resources | Work |
| --- | --- | --- | --- | --- | --- | --- | --- | --- | --- |
| 1 | 1 | **Project Management** | 12d | 1999-05-03 | 1999-05-14 |  | 0d |  | 816h |
| 2 | 1.1 | **Conceive New Project** | 1d | 1999-05-03 | 1999-05-03 |  | 0d |  | 32h |
| 3 | 1.1.1 | Identify and Assess Risks | 1d | 1999-05-03 | 1999-05-03 |  | 0d | Project Manager | 8h |
| 4 | 1.1.2 | Develop Business Case | 1d | 1999-05-03 | 1999-05-03 |  | 2d | Project Manager | 8h |
| 5 | 1.1.3 | Initiate Project | 1d | 1999-05-03 | 1999-05-03 |  | 2d | Project Manager | 8h |
| 6 | 1.1.4 | Project Approval Review | 1d | 1999-05-03 | 1999-05-03 |  | 2d | Project Reviewer | 8h |
| 7 | 1.2 | **Evaluate Project Scope and Risk** | 1d | 1999-05-04 | 1999-05-04 | 3 | 0d |  | 16h |
| 8 | 1.2.1 | Identify and Assess Risks | 1d | 1999-05-04 | 1999-05-04 |  | 0d | Project Manager | 8h |
| 9 | 1.2.2 | Develop Business Case | 1d | 1999-05-04 | 1999-05-04 |  | 10d | Project Manager | 8h |
| 10 | 1.3 | **Develop Software Development Plan** | 1d | 1999-05-05 | 1999-05-05 | 65SS, 8 | 0d |  | 72h |
| 11 | 1.3.1 | Develop Measurement Plan | 1d | 1999-05-05 | 1999-05-05 |  | 0d | Project Manager | 8h |
| 12 | 1.3.2 | Develop Risk Management Plan | 1d | 1999-05-05 | 1999-05-05 |  | 9d | Project Manager | 8h |
| 13 | 1.3.3 | Develop Product Acceptance Plan | 1d | 1999-05-05 | 1999-05-05 |  | 9d | Project Manager | 8h |
| 14 | 1.3.4 | Develop Problem Resolution Plan | 1d | 1999-05-05 | 1999-05-05 |  | 9d | Project Manager | 8h |
| 15 | 1.3.5 | Define Project Organization and Staffing | 1d | 1999-05-05 | 1999-05-05 |  | 9d | Project Manager | 8h |
| 16 | 1.3.6 | Define Monitoring & Control Processes | 1d | 1999-05-05 | 1999-05-05 |  | 9d | Project Manager | 8h |
| 17 | 1.3.7 | Plan Phases and Iterations | 1d | 1999-05-05 | 1999-05-05 |  | 9d | Project Manager | 8h |
| 18 | 1.3.8 | Compile Software Development Plan | 1d | 1999-05-05 | 1999-05-05 |  | 9d | Project Manager | 8h |
| 19 | 1.3.9 | Project Planning Review | 1d | 1999-05-05 | 1999-05-05 |  | 9d | Project Reviewer | 8h |
| 20 | 1.4 | **Plan Remainder of Initial Iteration** | 1d | 1999-05-06 | 1999-05-06 | 11 | 0d |  | 24h |
| 21 | 1.4.1 | Develop Iteration Plan | 1d | 1999-05-06 | 1999-05-06 |  | 0d | Project Manager | 8h |
| 22 | 1.4.2 | Develop Business Case | 1d | 1999-05-06 | 1999-05-06 |  | 0d | Project Manager | 8h |
| 23 | 1.4.3 | Iteration Plan Review | 1d | 1999-05-06 | 1999-05-06 |  | 0d | Project Reviewer | 8h |
| 24 | 1.5 | **Manage Iteration** | 6d | 1999-05-07 | 1999-05-12 | 21 | 0d |  | 240h |
| 25 | 1.5.1 | Acquire Staff | 6d | 1999-05-07 | 1999-05-12 |  | 0d | Project Manager | 48h |
| 26 | 1.5.2 | Initiate Iteration | 6d | 1999-05-07 | 1999-05-12 |  | 0d | Project Manager | 48h |
| 27 | 1.5.3 | Assess Iteration | 6d | 1999-05-07 | 1999-05-12 | 86FF | 0d | Project Manager | 48h |
| 28 | 1.5.4 | Iteration Evaluation Criteria Review | 6d | 1999-05-07 | 1999-05-12 |  | 0d | Project Reviewer | 48h |
| 29 | 1.5.5 | Iteration Acceptance Review | 6d | 1999-05-07 | 1999-05-12 |  | 0d | Project Reviewer | 48h |

| ID | WBS | Task | Duration | Start | Finish | Predecessors | Total slack | Free slack | Resources | Work |
| --- | --- | --- | --- | --- | --- | --- | --- | --- | --- | --- |
| 30 | 1.6 | **Monitor and Control Project** | 8d | 1999-05-07 | 1999-05-14 | 24SS, 21 | 0d |  |  | 320h |
| 31 | 1.6.1 | Schedule and Assign Work | 8d | 1999-05-07 | 1999-05-14 |  | 0d |  | Project Manager | 64h |
| 32 | 1.6.2 | Monitor Project Status | 8d | 1999-05-07 | 1999-05-14 |  | 0d |  | Project Manager | 64h |
| 33 | 1.6.3 | Report Status | 8d | 1999-05-07 | 1999-05-14 |  | 0d |  | Project Manager | 64h |
| 34 | 1.6.4 | Handle Exceptions and Problems | 8d | 1999-05-07 | 1999-05-14 |  | 0d |  | Project Manager | 64h |
| 35 | 1.6.5 | Project Review Authority (PRA) Project Review | 8d | 1999-05-07 | 1999-05-14 |  | 0d |  | Project Reviewer | 64h |
| 36 | 1.7 | **Reevaluate Project Scope and Risk** | 1d | 1999-05-13 | 1999-05-13 | 24 | 0d |  |  | 16h |
| 37 | 1.7.1 | Identify and Assess Risks | 1d | 1999-05-13 | 1999-05-13 |  | 0d |  | Project Manager | 8h |
| 38 | 1.7.2 | Develop Business Case | 1d | 1999-05-13 | 1999-05-13 |  | 0d |  | Project Manager | 8h |
| 39 | 1.8 | **Plan for Next Iteration** | 1d | 1999-05-14 | 1999-05-14 | 36 | 0d |  |  | 24h |
| 40 | 1.8.1 | Develop Iteration Plan | 1d | 1999-05-14 | 1999-05-14 |  | 0d |  | Project Manager | 8h |
| 41 | 1.8.2 | Develop Business Case | 1d | 1999-05-14 | 1999-05-14 |  | 0d |  | Project Manager | 8h |
| 42 | 1.8.3 | Iteration Plan Review | 1d | 1999-05-14 | 1999-05-14 | 52FF | 0d |  | Project Reviewer | 8h |
| 43 | 1.9 | **Refine Software Development Plan** | 1d | 1999-05-14 | 1999-05-14 | 36 | 0d |  |  | 72h |
| 44 | 1.9.1 | Develop Measurement Plan | 1d | 1999-05-14 | 1999-05-14 |  | 0d |  | Project Manager | 8h |
| 45 | 1.9.2 | Develop Risk Management Plan | 1d | 1999-05-14 | 1999-05-14 |  | 0d |  | Project Manager | 8h |
| 46 | 1.9.3 | Develop Product Acceptance Plan | 1d | 1999-05-14 | 1999-05-14 |  | 0d |  | Project Manager | 8h |
| 47 | 1.9.4 | Develop Problem Resolution Plan | 1d | 1999-05-14 | 1999-05-14 |  | 0d |  | Project Manager | 8h |
| 48 | 1.9.5 | Define Project Organization and Staffing | 1d | 1999-05-14 | 1999-05-14 |  | 0d |  | Project Manager | 8h |
| 49 | 1.9.6 | Define Monitoring & Control Processes | 1d | 1999-05-14 | 1999-05-14 |  | 0d |  | Project Manager | 8h |
| 50 | 1.9.7 | Plan Phases and Iterations | 1d | 1999-05-14 | 1999-05-14 |  | 0d |  | Project Manager | 8h |
| 51 | 1.9.8 | Compile Software Development Plan | 1d | 1999-05-14 | 1999-05-14 |  | 0d |  | Project Manager | 8h |
| 52 | 1.9.9 | Project Planning Review | 1d | 1999-05-14 | 1999-05-14 |  | 0d |  | Project Reviewer | 8h |
| 53 | 2 | **Requirements** | 11d | 1999-05-03 | 1999-05-13 |  | 1d |  |  | 768h |
| 54 | 2.1 | **Analyze the Problem** | 4d | 1999-05-03 | 1999-05-06 | 2SS, 59SS | 8d | 0d |  | 128h |
| 55 | 2.1.1 | Capture a Common Vocabulary | 4d | 1999-05-03 | 1999-05-06 |  | 8d |  | System Analyst | 32h |
| 56 | 2.1.2 | Find Actors and Use Cases | 4d | 1999-05-03 | 1999-05-06 |  | 8d |  | System Analyst | 32h |
| 57 | 2.1.3 | Develop Vision | 4d | 1999-05-03 | 1999-05-06 |  | 8d |  | System Analyst | 32h |
| 58 | 2.1.4 | Develop Requirements Management Plan | 4d | 1999-05-03 | 1999-05-06 |  | 8d |  | System Analyst | 32h |

| ID | WBS | Task | Duration | Start | Finish | Predecessors | Total slack | Free slack | Resources | Work |
| --- | --- | --- | --- | --- | --- | --- | --- | --- | --- | --- |
| 59 | 2.2 | **Understand Stakeholder Needs** | 4d | 1999-05-03 | 1999-05-06 | 2SS | 8d | 0d |  | 160h |
| 60 | 2.2.1 | Capture a Common Vocabulary | 4d | 1999-05-03 | 1999-05-06 |  | 8d |  | System Analyst | 32h |
| 61 | 2.2.2 | Elicit Stakeholder Requests | 4d | 1999-05-03 | 1999-05-06 |  | 8d |  | System Analyst | 32h |
| 62 | 2.2.3 | Develop Vision | 4d | 1999-05-03 | 1999-05-06 |  | 8d |  | System Analyst | 32h |
| 63 | 2.2.4 | Find Actors and Use Cases | 4d | 1999-05-03 | 1999-05-06 |  | 8d |  | System Analyst | 32h |
| 64 | 2.2.5 | Manage Dependencies | 4d | 1999-05-03 | 1999-05-06 |  | 8d |  | System Analyst | 32h |
| 65 | 2.3 | **Define the System** | 3d | 1999-05-04 | 1999-05-06 | 2 | 4d | 0d |  | 72h |
| 66 | 2.3.1 | Capture a Common Vocabulary | 3d | 1999-05-04 | 1999-05-06 |  | 4d |  | System Analyst | 24h |
| 67 | 2.3.2 | Find Actors and Use Cases | 3d | 1999-05-04 | 1999-05-06 |  | 4d |  | System Analyst | 24h |
| 68 | 2.3.3 | Manage Dependencies | 3d | 1999-05-04 | 1999-05-06 |  | 4d |  | System Analyst | 24h |
| 69 | 2.4 | **Manage the Scope of the System** | 3d | 1999-05-05 | 1999-05-07 | 65SS+1d | 4d |  |  | 64h |
| 70 | 2.4.1 | Develop Vision | 3d | 1999-05-05 | 1999-05-07 |  | 7d |  | System Analyst | 24h |
| 71 | 2.4.2 | Manage Dependencies | 3d | 1999-05-05 | 1999-05-07 |  | 7d |  | System Analyst | 24h |
| 72 | 2.4.3 | Prioritize Use Cases | 2d | 1999-05-05 | 1999-05-06 |  | 4d | 0d | Software Architect | 16h |
| 73 | 2.5 | **Refine the System Definition** | 4d | 1999-05-07 | 1999-05-10 | 20, 65, 72 | 4d |  |  | 128h |
| 74 | 2.5.1 | Detail a Use Case | 4d | 1999-05-07 | 1999-05-10 |  | 4d |  | Use-Case Specifier | 32h |
| 75 | 2.5.2 | Detail the Software Requirements | 4d | 1999-05-07 | 1999-05-10 |  | 4d |  | Use-Case Specifier | 32h |
| 76 | 2.5.3 | Model the User Interface | 4d | 1999-05-07 | 1999-05-10 |  | 4d |  | User-Interface Designer | 32h |
| 77 | 2.5.4 | Prototype the User Interface | 4d | 1999-05-07 | 1999-05-10 |  | 4d |  | User-Interface Designer | 32h |
| 78 | 2.6 | **Manage Changing Requirements** | 9d | 1999-05-05 | 1999-05-13 | 54SS+2d | 1d |  |  | 216h |
| 79 | 2.6.1 | Structure the Use-Case Model | 9d | 1999-05-05 | 1999-05-13 |  | 1d |  | System Analyst | 72h |
| 80 | 2.6.2 | Manage Dependencies | 9d | 1999-05-05 | 1999-05-13 |  | 1d |  | System Analyst | 72h |
| 81 | 2.6.3 | Review Requirements | 9d | 1999-05-05 | 1999-05-13 |  | 1d |  | Requirements Reviewer | 72h |
| 82 | 3 | **Analysis and Design** | 6d | 1999-05-07 | 1999-05-12 |  | 0d |  |  | 144h |
| 83 | 3.1 | **Perform Architectural Synthesis** | 6d | 1999-05-07 | 1999-05-12 | 20 | 0d |  |  | 144h |
| 84 | 3.1.1 | Architectural Analysis | 6d | 1999-05-07 | 1999-05-12 |  | 2d |  | Software Architect | 48h |
| 85 | 3.1.2 | Construct Architectural Proof-of-Concept | 6d | 1999-05-07 | 1999-05-12 |  | 2d |  | Software Architect | 48h |
| 86 | 3.1.3 | Assess Viability of Architectural Proof-of-Concept | 6d | 1999-05-07 | 1999-05-12 |  | 0d |  | Software Architect | 48h |

| ID | WBS | Task | Duration | Start | Finish | Predecessors | Total slack | Free slack | Resources | Work |
| --- | --- | --- | --- | --- | --- | --- | --- | --- | --- | --- |
| 87 | 4 | **Test** | 1d | 1999-05-05 | 1999-05-05 |  | 9d |  |  | 8h |
| 88 | 4.1 | **Plan Test** | 1d | 1999-05-05 | 1999-05-05 | 10SS | 9d |  |  | 8h |
| 89 | 4.1.1 | Plan Test | 1d | 1999-05-05 | 1999-05-05 |  | 9d |  | Test Designer | 8h |
| 90 | 5 | **Environment** | 10d | 1999-05-04 | 1999-05-13 |  | 1d |  |  | 192h |
| 91 | 5.1 | **Prepare Environment for Project** | 1d | 1999-05-04 | 1999-05-04 | 2 | 2d | 1d |  | 32h |
| 92 | 5.1.1 | Assess Current Organization | 1d | 1999-05-04 | 1999-05-04 |  | 2d | 1d | Process Engineer | 8h |
| 93 | 5.1.2 | Develop Development Case | 1d | 1999-05-04 | 1999-05-04 |  | 9d |  | Process Engineer | 8h |
| 94 | 5.1.3 | Develop Project-Specific Templates | 1d | 1999-05-04 | 1999-05-04 |  | 9d |  | Process Engineer | 8h |
| 95 | 5.1.4 | Select & Acquire Tools | 1d | 1999-05-04 | 1999-05-04 |  | 9d |  | Tool Specialist | 8h |
| 96 | 5.2 | **Prepare Environment for an Iteration** | 1d | 1999-05-06 | 1999-05-06 | 20SS, 92 | 1d | 0d |  | 40h |
| 97 | 5.2.1 | Develop Development Case | 1d | 1999-05-06 | 1999-05-06 |  | 1d |  | Process Engineer | 8h |
| 98 | 5.2.2 | Develop Project-Specific Templates | 1d | 1999-05-06 | 1999-05-06 |  | 1d |  | Process Engineer | 8h |
| 99 | 5.2.3 | Launch Development Case | 1d | 1999-05-06 | 1999-05-06 |  | 1d |  | Process Engineer | 8h |
| 100 | 5.2.4 | Set Up Tools | 1d | 1999-05-06 | 1999-05-06 |  | 1d |  | Tool Specialist | 8h |
| 101 | 5.2.5 | Verify Tool Configuration & Installation | 1d | 1999-05-06 | 1999-05-06 |  | 1d |  | Tool Specialist | 8h |
| 102 | 5.3 | **Prepare Guidelines for an Iteration** | 1d | 1999-05-06 | 1999-05-06 | 91, 20SS | 8d |  |  | 64h |
| 103 | 5.3.1 | Develop Business-Modeling Guidelines | 1d | 1999-05-06 | 1999-05-06 |  | 8d |  | Business-Process Analyst | 8h |
| 104 | 5.3.2 | Develop Use-Case Modeling Guidelines | 1d | 1999-05-06 | 1999-05-06 |  | 8d |  | System Analyst | 8h |
| 105 | 5.3.3 | Develop User-Interface Guidelines | 1d | 1999-05-06 | 1999-05-06 |  | 8d |  | User-Interface Designer | 8h |
| 106 | 5.3.4 | Develop Design Guidelines | 1d | 1999-05-06 | 1999-05-06 |  | 8d |  | Software Architect | 8h |
| 107 | 5.3.5 | Develop Programming Guidelines | 1d | 1999-05-06 | 1999-05-06 |  | 8d |  | Software Architect | 8h |
| 108 | 5.3.6 | Develop Manual Styleguide | 1d | 1999-05-06 | 1999-05-06 |  | 8d |  | Technical Writer | 8h |
| 109 | 5.3.7 | Develop Test Guidelines | 1d | 1999-05-06 | 1999-05-06 |  | 8d |  | Test Designer | 8h |
| 110 | 5.3.8 | Develop Tool Guidelines | 1d | 1999-05-06 | 1999-05-06 |  | 8d |  | Tool Specialist | 8h |

| ID | WBS | Task | Duration | Start | Finish | Predecessors | Total slack | Free slack | Resources | Work |
| --- | --- | --- | --- | --- | --- | --- | --- | --- | --- | --- |
| 111 | 5.4 | **Support Environment During an Iteration** | 7d | 1999-05-07 | 1999-05-13 | 96 | 1d |  |  | 56h |
| 112 | 5.4.1 | Support Development | 7d | 1999-05-07 | 1999-05-13 |  | 1d |  | System Administrator | 56h |
| 113 | 6 | **Configuration & Change Management** | 10d | 1999-05-04 | 1999-05-13 |  | 1d |  |  | 824h |
| 114 | 6.1 | **Plan Project Configuration and Change Control** | 1d | 1999-05-04 | 1999-05-04 | 2 | 2d |  |  | 24h |
| 115 | 6.1.1 | Establish CM Policies | 1d | 1999-05-04 | 1999-05-04 |  | 2d | 1d | Configuration Manager | 8h |
| 116 | 6.1.2 | Write CM Plan | 1d | 1999-05-04 | 1999-05-04 |  | 10d |  | Configuration Manager | 8h |
| 117 | 6.1.3 | Establish Change Control Process | 1d | 1999-05-04 | 1999-05-04 |  | 10d |  | Change Control Manager | 8h |
| 118 | 6.2 | **Create Project CM Environments** | 1d | 1999-05-06 | 1999-05-06 | 20SS, 115 | 1d | 0d |  | 16h |
| 119 | 6.2.1 | Setup CM Environment | 1d | 1999-05-06 | 1999-05-06 |  | 1d |  | Configuration Manager | 8h |
| 120 | 6.2.2 | Create Integration Workspaces | 1d | 1999-05-06 | 1999-05-06 |  | 1d |  | Integrator | 8h |
| 121 | 6.3 | **Change and Deliver Configuration Items** | 6d | 1999-05-07 | 1999-05-12 | 118 | 2d |  |  | 288h |
| 122 | 6.3.1 | Create Development Workspace | 6d | 1999-05-07 | 1999-05-12 |  | 2d |  | Any Worker | 48h |
| 123 | 6.3.2 | Make Changes | 6d | 1999-05-07 | 1999-05-12 |  | 2d |  | Any Worker | 48h |
| 124 | 6.3.3 | Deliver Changes | 6d | 1999-05-07 | 1999-05-12 |  | 2d |  | Any Worker | 48h |
| 125 | 6.3.4 | Update Workspace | 6d | 1999-05-07 | 1999-05-12 |  | 2d |  | Any Worker | 48h |
| 126 | 6.3.5 | Create Baselines | 6d | 1999-05-07 | 1999-05-12 |  | 2d |  | Integrator | 48h |
| 127 | 6.3.6 | Promote Baselines | 6d | 1999-05-07 | 1999-05-12 |  | 2d |  | Integrator | 48h |
| 128 | 6.4 | **Manage Baselines and Releases** | 6d | 1999-05-07 | 1999-05-12 | 118, 24SS | 2d |  |  | 144h |
| 129 | 6.4.1 | Create Deployment Unit | 6d | 1999-05-07 | 1999-05-12 |  | 2d |  | Configuration Manager | 48h |
| 130 | 6.4.2 | Create Baselines | 6d | 1999-05-07 | 1999-05-12 |  | 2d |  | Integrator | 48h |
| 131 | 6.4.3 | Promote Baselines | 6d | 1999-05-07 | 1999-05-12 |  | 2d |  | Integrator | 48h |
| 132 | 6.5 | **Manage Change Requests** | 6d | 1999-05-07 | 1999-05-12 | 118, 24SS | 2d |  |  | 240h |
| 133 | 6.5.1 | Submit Change Request | 6d | 1999-05-07 | 1999-05-12 |  | 2d |  | Any Worker | 48h |
| 134 | 6.5.2 | Update Change Request | 6d | 1999-05-07 | 1999-05-12 |  | 2d |  | Any Worker | 48h |
| 135 | 6.5.3 | Review Change Request | 6d | 1999-05-07 | 1999-05-12 |  | 2d |  | Change Control Manager | 48h |
| 136 | 6.5.4 | Confirm Duplicate or Rejected Change Request | 6d | 1999-05-07 | 1999-05-12 |  | 2d |  | Change Control Manager | 48h |
| 137 | 6.5.5 | Verify Changes in Build | 6d | 1999-05-07 | 1999-05-12 |  | 2d |  | Integrator | 48h |

| ID | WBS | Task | Duration | Start | Finish | Predecessors | Total slack | Resources | Work |
| --- | --- | --- | --- | --- | --- | --- | --- | --- | --- |
| 138 | 6.6 | **Monitor and Report Configuration Status** | 7d | 1999-05-07 | 1999-05-13 | 118, 24SS | 1d |  | 112h |
| 139 | 6.6.1 | Report on Configuration Status | 7d | 1999-05-07 | 1999-05-13 |  | 1d | Configuration Manager | 56h |
| 140 | 6.6.2 | Perform Configuration Audits | 7d | 1999-05-07 | 1999-05-13 |  | 1d | Configuration Manager | 56h |
